# 2010 Schedule~156

Schedule from MS Project, 2010-02-01 to 2010-12-31, A marks actual dates.
MBARI

## Calendars

- Standard: Mon-Fri 08:00-12:00, 13:00-17:00; Sat-Sun off.

## Resources

| Resource |
| --- |
| Gordon |
| Moe |
| Betty |
| NEO |
| Bruce |
| MaCK |

## Schedule

| ID | WBS | Task | Duration | Start | Finish | Complete | Remaining | Total slack | Constraint | Resources | Work |
| --- | --- | --- | --- | --- | --- | --- | --- | --- | --- | --- | --- |
| 1 | 1 | **Shallow Deployment Leap 1** | 78d? | 2010-02-02 A | 2010-05-20 | 4% | 74.84d? | 161d |  |  | 216h |
| 2 | 1.1 | Dates | 27d? | 2010-04-14 | 2010-05-20 |  |  | 161d | finish no earlier than 2010-05-20 | Moe | 216h |
| 3 | 1.2 | Convert to new Black Radio Box | 10d? | 2010-02-02 A | 2010-02-15 | 15% | 8.5d? | 229d | start no earlier than 2010-02-02 |  |  |
| 4 | 2 | **Shallow Deployment Leap 2** | 19d? | 2010-05-20 | 2010-06-15 |  |  | 143d |  |  | 152h |
| 5 | 2.1 | Dates | 19d? | 2010-05-20 | 2010-06-15 |  |  | 143d | finish no earlier than 2010-06-15 | NEO | 152h |
| 6 | 3 | **Shallow Deployment Leap 3** | 21d? | 2010-06-15 | 2010-07-13 |  |  | 123d |  |  | 168h |
| 7 | 3.1 | Dates | 21d? | 2010-06-15 | 2010-07-13 |  |  | 123d | finish no earlier than 2010-07-13 | Moe | 168h |
| 8 | 4 | **Shallow Deployment Leap 4** | 23d? | 2010-07-13 | 2010-08-12 |  |  | 101d |  |  | 184h |
| 9 | 4.1 | Dates | 23d? | 2010-07-13 | 2010-08-12 |  |  | 101d | finish no earlier than 2010-08-12 | NEO | 184h |
| 10 | 5 | **Deep South Deployment** | 128d? | 2010-02-01 A | 2010-07-28 | 1% | 126.44d? | 112d |  |  | 56h |
| 11 | 5.1 | Dates | 7d? | 2010-07-20 | 2010-07-28 |  |  | 112d | finish no earlier than 2010-07-28 | Gordon | 56h |
| 13 | 5.2 | Fix Pressure Switches | 4d? | 2010-02-08 | 2010-02-11 |  |  | 231d | finish no earlier than 2010-02-11 |  |  |
| 14 | 5.3 | **Acoustic Modem** | 100d? | 2010-02-01 A | 2010-06-18 | 3% | 97.01d? | 140d |  |  |  |
| 15 | 5.3.1 | Power Calculation | 2d? | 2010-02-01 A | 2010-02-02 A | 100% |  |  | finish no earlier than 2010-02-02 |  |  |
| 16 | 5.3.2 | Cable Molding | 1d? | 2010-02-04 A | 2010-02-04 | 15% | 0.85d? | 236d |  |  |  |
| 17 | 5.3.3 | Modem to Modem testing | 5d? | 2010-03-01 | 2010-03-05 |  |  | 215d | finish no earlier than 2010-03-05 |  |  |
| 18 | 5.3.4 | Burn wire checkout | 1d? | 2010-02-04 | 2010-02-04 |  |  | 236d |  |  |  |
| 19 | 5.3.5 | Mounting | 1d? | 2010-02-04 | 2010-02-04 |  |  | 236d |  |  |  |
| 20 | 5.3.6 | Sea Water Ground for Burn wire | 1d? | 2010-02-04 | 2010-02-04 |  |  | 236d |  |  |  |
| 21 | 5.3.7 | Drop Release drawings | 3d? | 2010-02-04 | 2010-02-08 |  |  | 234d | finish no earlier than 2010-02-08 |  |  |
| 22 | 5.3.8 | Burn wire fabrication and assembly | 45d? | 2010-02-08 | 2010-04-09 |  |  | 190d | start no earlier than 2010-02-08 |  |  |
| 23 | 5.3.9 | Drop weight testing | 5d? | 2010-04-12 | 2010-04-16 |  |  | 185d | start no earlier than 2010-04-12 |  |  |
| 24 | 5.3.10 | Burn wire testing | 5d? | 2010-06-14 | 2010-06-18 |  |  | 140d | finish no earlier than 2010-06-18 |  |  |
| 25 | 5.3.11 | test tank test | 1d? | 2010-02-04 | 2010-02-04 |  |  | 236d |  |  |  |
| 26 | 5.3.12 | topside baffle | 1d? | 2010-02-04 | 2010-02-04 |  |  | 236d |  |  |  |
| 27 | 5.3.13 | ROV interferance | 1d? | 2010-02-04 | 2010-02-04 |  |  | 236d |  |  |  |

Notes:
- 3: Paul currenlty working on 4 feb 10, to be complete 12 feb 10
- 13: DWSM Sampler opened and found switches functional / Current plan is to reassemle and then leave for a couple of weeks with pressure
- 15: (28AHr-2.5AHr)*1200bps*450/2 = 6.8Mbytes / Should be enough if nothing more than check on status
- 16: All cables present, drawing ready, waiting for lengths
- 26: Needs balast plate fabricated and installed.

| ID | WBS | Task | Duration | Start | Finish | Total slack | Constraint |
| --- | --- | --- | --- | --- | --- | --- | --- |
| 28 | 5.4 | **Elevator Additions** | 1d? | 2010-02-04 | 2010-02-04 | 236d |  |
| 29 | 5.4.1 | Weight and balance | 1d? | 2010-02-04 | 2010-02-04 | 236d |  |
| 30 | 5.4.2 | Retrieve Foam from Castroville | 1d? | 2010-02-04 | 2010-02-04 | 236d |  |
| 31 | 5.4.3 | Add Foam to Elevator | 1d? | 2010-02-04 | 2010-02-04 | 236d |  |
| 32 | 5.4.4 | Weight Limits | 1d? | 2010-02-04 | 2010-02-04 | 236d |  |
| 33 | 5.5 | **Sphere Bulkhead valves** | 32d? | 2010-02-05 | 2010-03-22 | 204d |  |
| 34 | 5.5.1 | Purchase new originals to replace | 32d? | 2010-02-05 | 2010-03-22 | 204d | start no earlier than 2010-02-05 |
| 35 | 5.6 | **Wand** | 12d? | 2010-02-04 | 2010-02-19 | 225d |  |
| 36 | 5.6.1 | Test Valve | 4d? | 2010-02-16 | 2010-02-19 | 225d | finish no earlier than 2010-02-19 |
| 37 | 5.6.2 | Management/Deploy/Recover | 1d? | 2010-02-04 | 2010-02-04 | 236d |  |
| 38 | 5.6.3 | cable | 1d? | 2010-02-04 | 2010-02-04 | 236d |  |
| 39 | 5.7 | Sphere Heater | 1d? | 2010-02-04 | 2010-02-04 | 236d |  |
| 40 | 5.8 | **70m Cable Management** | 4d? | 2010-02-04 | 2010-02-09 | 233d |  |
| 41 | 5.8.1 | Dead ROV release | 1d? | 2010-02-04 | 2010-02-04 | 236d |  |
| 42 | 5.8.2 | Yale Grips | 3d? | 2010-02-05 | 2010-02-09 | 233d | finish no earlier than 2010-02-09 |
| 43 | 5.9 | Sphere Vent Port | 1d? | 2010-02-04 | 2010-02-04 | 236d |  |
| 44 | 5.10 | **ISMS** | 1d? | 2010-02-04 | 2010-02-04 | 236d |  |
| 45 | 5.10.1 | Initial assemsment | 1d? | 2010-02-04 | 2010-02-04 | 236d |  |
| 46 | 5.10.2 | Final agreement | 1d? | 2010-02-04 | 2010-02-04 | 236d |  |
| 47 | 5.10.3 | Computer Power Supply | 1d? | 2010-02-04 | 2010-02-04 | 236d |  |
| 48 | 5.10.4 | Ball wiring | 1d? | 2010-02-04 | 2010-02-04 | 236d |  |
| 49 | 5.10.5 | Combiner wiring | 1d? | 2010-02-04 | 2010-02-04 | 236d |  |
| 50 | 5.10.6 | Software | 1d? | 2010-02-04 | 2010-02-04 | 236d |  |
| 51 | 5.10.7 | Testing | 1d? | 2010-02-04 | 2010-02-04 | 236d |  |

Notes:
- 34: Valves on order 6weeks / -D / 5 feb 10
- 46: 1. A completely sealed unit will be attached to the DWSM elevator / 2.Cables providing RS-232 and power will be attached to the mass spec on the deck of the ship / 3.Power is applied, but neither roughing or high vacuum pumps have been started / 4.The elevator will be lowered into the water and then released. / 5.The elevator will fall into position / 6.The ROV will locate the elevator, DWSM, mass spec and attach an Ethernet cable to the DWSM / 7.The roughing pump will be started and allowed to run for 5 minutes / 8.The high vacuum pump will be started and allowed to run for 10 minutes / 9.The RGA will be activated from the surface and scans will be started / 10.The mass spectrometer will remain unattended for three days gathering data / 11.Step #6 will be repeated at the end of the deployment / 12.The RGA, high vacuum and roughing pumps will be turned off / 13.Weights will be dropped and the elevator, DWSM and mass spec will return to the surface / 14.The elevator, DWSM and mass spectrometer will be loaded onto the ship with a crane
- 47: 5V at 15W

| ID | WBS | Task | Duration | Start | Finish | Total slack | Constraint | Resources | Work |
| --- | --- | --- | --- | --- | --- | --- | --- | --- | --- |
| 52 | 5.11 | **IEP** | 5d? | 2010-02-05 | 2010-02-11 | 231d |  |  |  |
| 53 | 5.11.1 | Worn old pump characterize | 4d? | 2010-02-08 | 2010-02-11 | 231d | start no earlier than 2010-02-08 |  |  |
| 54 | 5.11.2 | Ivec pump speicification | 1d? | 2010-02-05 | 2010-02-05 | 235d | start no earlier than 2010-02-05 |  |  |
| 59 | 5.12 | **Integrated system test in test tank** | 107d? | 2010-02-04 | 2010-07-02 | 130d |  |  |  |
| 60 | 5.12.1 | Dry testing | 11d? | 2010-05-31 | 2010-06-14 | 144d | finish no earlier than 2010-06-14 |  |  |
| 61 | 5.12.2 | Testtank | 15d? | 2010-06-14 | 2010-07-02 | 130d | finish no earlier than 2010-07-02 |  |  |
| 62 | 5.12.3 | Drop release | 1d? | 2010-02-04 | 2010-02-04 | 236d |  |  |  |
| 63 | 5.12.4 | Burn Release | 1d? | 2010-02-04 | 2010-02-04 | 236d |  |  |  |
| 64 | 5.12.5 | Weight Balance | 1d? | 2010-02-04 | 2010-02-04 | 236d |  |  |  |
| 65 | 5.12.6 | Post can QC | 1d? | 2010-02-04 | 2010-02-04 | 236d |  |  |  |
| 66 | 5.12.7 | Lung function | 1d? | 2010-02-04 | 2010-02-04 | 236d |  |  |  |
| 67 | 5.12.8 | Communications test | 1d? | 2010-02-04 | 2010-02-04 | 236d |  |  |  |
| 71 | 6 | **MARS Deployment** | 110d? | 2010-08-02 | 2010-12-31 | 0d |  |  | 200h |
| 72 | 6.1 | Dates | 25d? | 2010-11-29 | 2010-12-31 | 0d | finish no earlier than 2010-12-31 | Gordon | 200h |
| 73 | 6.2 | Cable Management | 1d? | 2010-08-02 | 2010-08-02 | 109d | start no earlier than 2010-08-02 |  |  |
| 74 | 7 | **South Deployment** | 62d? | 2010-02-04 | 2010-04-30 | 175d |  |  | 352h |
| 75 | 7.1 | Dates | 22d? | 2010-04-01 | 2010-04-30 | 175d | finish no earlier than 2010-04-30 |  |  |
| 76 | 7.2 | Mooring 1 | 22d? | 2010-04-01 | 2010-04-30 | 175d | finish no earlier than 2010-04-30 | Bruce | 176h |
| 77 | 7.3 | Mooring 2 | 22d? | 2010-04-01 | 2010-04-30 | 175d | finish no earlier than 2010-04-30 | MaCK | 176h |
| 78 | 7.4 | Pier | 22d? | 2010-04-01 | 2010-04-30 | 175d | finish no earlier than 2010-04-30 |  |  |
| 79 | 7.5 | Order Batteries | 1d? | 2010-02-04 | 2010-02-04 | 236d |  |  |  |
| 80 | 7.6 | Site visit | 1d? | 2010-02-04 | 2010-02-04 | 236d |  |  |  |
| 81 | 7.7 | Communications Plan | 1d? | 2010-02-04 | 2010-02-04 | 236d |  |  |  |
| 82 | 7.8 | Deployment and Recovery Plan | 1d? | 2010-02-04 | 2010-02-04 | 236d |  |  |  |
| 83 | 7.9 | Shipping Plan | 1d? | 2010-02-04 | 2010-02-04 | 236d |  |  |  |
| 85 | 8 | MB Network Deployment Mooring 1 | 26d? | 2010-09-29 | 2010-11-03 | 42d | finish no earlier than 2010-11-03 |  |  |
| 86 | 9 | MB Network Deployment Mooring 2 | 26d? | 2010-09-29 | 2010-11-03 | 42d | finish no earlier than 2010-11-03 |  |  |
| 87 | 10 | MB Network Deployment Mooring 3 | 26d? | 2010-09-29 | 2010-11-03 | 42d | finish no earlier than 2010-11-03 |  |  |
| 88 | 11 | MFB Training | 1d? | 2010-02-04 | 2010-02-04 | 236d |  |  |  |
| 89 | 12 | In-Lab test Deployment PCR | 1d? | 2010-02-04 | 2010-02-04 | 236d |  | Moe | 8h |
| 90 | 13 | In-Lab test deployment new instrument | 1d? | 2010-02-04 | 2010-02-04 | 236d |  | Betty | 8h |

Notes:
- 82: Contacted Danny Warren at SCMI; Seawatch to small consider Yellowfin. Need to send deplyoment document ofr their review.
